Schedule from MS Project, 2016-01-25 to 2016-01-29.
Microsoft

## Calendars

- 标准: Mon-Fri 08:00-12:00, 13:00-17:00; Sat-Sun off.

## Resources

| Resource |
| --- |
| 杨立君 |
| 王宏伟 |
| 李中声 |
| 任黎明 |
| 葛并 |
| 崔进京 |
| 王英慧 |
| 张琳璐 |

## Schedule

| ID | WBS | Task | Type | Duration | Start | Finish | Predecessors | Total slack | Constraint | Resources | Work |
| --- | --- | --- | --- | --- | --- | --- | --- | --- | --- | --- | --- |
| 1 | 1 | **版权系统** |  | 5d | 2016-01-25 | 2016-01-29 |  |  |  |  | 195h |
| 2 | 1.1 | **2016年1月第四周** |  | 5d | 2016-01-25 | 2016-01-29 |  |  |  |  | 195h |
| 3 | 1.1.1 | 费用调整功能 |  | 2.88d | 2016-01-25 | 2016-01-27 |  | 0d | finish no earlier than 2016-01-27 | 任黎明 | 23h |
| 4 | 1.1.2 | 测试环境老工作流程同步更新新工作流和报表相关问题修改 |  | 2d | 2016-01-28 | 2016-01-29 | 3 | 0d |  | 任黎明 | 16h |
| 5 | 1.1.3 | 补充协议审批及PR审批后生成工作流开发 |  | 2.88d | 2016-01-25 | 2016-01-27 |  | 0d | finish no earlier than 2016-01-27 | 葛并; 任黎明 | 23h |
| 6 | 1.1.4 | 财务相关细节调整及bug修改 |  | 2d | 2016-01-28 | 2016-01-29 | 5 | 0d |  | 葛并 | 16h |
| 7 | 1.1.5 | 自制评估需求变更代码编写 |  | 1.88d | 2016-01-25 | 2016-01-26 |  | 0d | finish no earlier than 2016-01-26 | 崔进京 | 15h |
| 8 | 1.1.6 | 自制评估、立项、合同、费用技术文档编写 |  | 1d | 2016-01-27 | 2016-01-27 | 7 | 0d | finish no earlier than 2016-01-18 | 崔进京 | 8h |
| 9 | 1.1.7 | 自制视频管理模块其他需求变更或bug修改 |  | 2d | 2016-01-28 | 2016-01-29 | 8 | 0d |  | 崔进京 | 16h |
| 10 | 1.1.8 | 按照剧集填写开发票，发票金额小于剧集金额可以开多次 |  | 0.88d | 2016-01-25 | 2016-01-25 |  | 0d | start no earlier than 2016-01-25 | 李中声 | 7h |
| 11 | 1.1.9 | 分销bug修复 |  | 1d | 2016-01-26 | 2016-01-26 | 10 | 0d |  | 李中声 | 8h |
| 12 | 1.1.10 | 财务分支后台工作流修改（具体再细分） | manual | 3d | 2016-01-27 | 2016-01-29 | 11 |  |  | 李中声 | 24h |
| 13 | 1.1.11 | 分销补充协议 分销审批完成后修改相关集数、金额、授权期限信息 |  | 0.88d | 2016-01-25 | 2016-01-25 |  | 0d | start no earlier than 2016-01-25 | 张琳璐 | 7h |
| 14 | 1.1.12 | 工作流同步代办接口添加日志记录 |  | 1d | 2016-01-26 | 2016-01-26 | 13 | 0d |  | 张琳璐 | 8h |
| 15 | 1.1.13 | 分销bug修复 | manual | 1d | 2016-01-27 | 2016-01-27 | 14 |  |  | 张琳璐 | 8h |
| 16 | 1.1.14 | 财务分支后台工作流修改（具体再细分） | manual | 2d | 2016-01-28 | 2016-01-29 | 15 |  |  | 张琳璐 | 16h |
